# PMBOK Compliant Project Management

Schedule from MS Project, 2013-08-21 to 2013-11-21.

## Calendars

- Standard: Mon-Fri 08:00-12:00, 13:00-17:00; Sat-Sun off.

## Resources

| Resource |
| --- |
| Project Director |
| Project Manager |
| Acceptor |
| Application Architect |
| Technical Architect |
| Quality Assurance Manager |
| Contracts Manager |
| Team Leader |

## Schedule

| ID | WBS | Task | Type | Duration | Start | Finish | Predecessors | Total slack | Free slack | Resources | Work | Text8 | PMBOK Knowledge Area | Deliverables | Text7 |
| --- | --- | --- | --- | --- | --- | --- | --- | --- | --- | --- | --- | --- | --- | --- | --- |
| 1 | 1 | Project Start | milestone | 0d | 2013-08-21 | 2013-08-21 |  | -4d | 0d |  |  |  |  |  |  |
| 2 | 2 | **Initiating** |  | 5d | 2013-08-21 | 2013-08-27 |  | -3d | 0d |  | 64h | {F3ECAA18-A899-4120-BB35-2C1D06EBFC42} |  |  |  |
| 3 | 2.1 | **Identified Stakeholders** |  | 4d | 2013-08-22 | 2013-08-27 |  | -4d | 0d |  | 24h |  | Project Stakeholder Management |  |  |
| 4 | 2.1.1 | Identify Project Stakeholders |  | 1d | 2013-08-22 | 2013-08-22 | 1 | -4d | 0d | Project Director | 8h |  | Project Stakeholder Management | List of Stakeholders | List of Stakeholders |
| 5 | 2.1.2 | Conduct Stakeholder Analysis |  | 1d | 2013-08-26 | 2013-08-26 | 4 | -2d | 0d | Project Director | 8h |  | Project Stakeholder Management | Stakeholder Analysis Grids | Stakeholder Analysis Grids |
| 6 | 2.1.3 | Generate Stakeholder Register |  | 1d | 2013-08-27 | 2013-08-27 | 5 | -2d | 0d | Project Director | 8h |  | Project Stakeholder Management | Stakeholder Register | Stakeholder Register |
| 7 | 2.1.4 | Stakeholder Analysis Complete | milestone | 0d | 2013-08-27 | 2013-08-27 | 6 | -2d | 0d |  |  |  | Project Stakeholder Management | Stakeholder Register | Stakeholder Register |
| 8 | 2.2 | **Project Charter** |  | 5d | 2013-08-21 | 2013-08-27 |  | -2d | 0d |  | 40h | {D09FBBEC-4AE3-4627-AF63-B09962B16A03} | Project Integration Management |  |  |
| 9 | 2.2.1 | Identify Goals and Objectives |  | 1d | 2013-08-21 | 2013-08-21 | 1 | -2d | 0d | Project Director | 8h | {9A64902B-9449-428C-8BCA-319C7F3294CC} | Project Integration Management | Goals and Objectives, List of Constraints | Goals and Objectives, List of Constraints |
| 10 | 2.2.2 | Develop Strategies and Plans |  | 1d | 2013-08-23 | 2013-08-23 | 9 | -2d | 0d | Project Director | 8h | {EA2B0290-55D4-4C9D-8154-195B49B53288} | Project Integration Management | Strategies and Plans | Strategies and Plans |
| 11 | 2.2.3 | Research Previous Experience |  | 1d | 2013-08-26 | 2013-08-26 | 10 | -2d | 0d | Project Manager | 8h | {188A9758-76CF-49CD-B2F8-12BB2367DAA5} | Project Integration Management | Sample Materials | Sample Materials |
| 12 | 2.2.4 | Develop Project Charter |  | 1d | 2013-08-27 | 2013-08-27 | 11 | -2d | 0d | Project Manager; Acceptor | 16h | {151ACF6D-1D6A-4204-A626-C3777486B053} | Project Integration Management | Project Charter | Project Charter |
| 13 | 2.2.5 | Project Charter Complete | milestone | 0d | 2013-08-27 | 2013-08-27 | 12 | -2d | 0d |  |  |  | Project Integration Management | Project Charter | Project Charter |
| 14 | 2.3 | Initiating Complete | milestone | 0d | 2013-08-27 | 2013-08-27 | 7, 13 | -2d | 0d |  |  |  |  |  |  |
| 15 | 3 | **Planning** |  | 34d | 2013-08-28 | 2013-10-14 |  | 1d |  |  | 396h | {E3B3021F-0960-4756-A1AF-225B36FC8667} |  |  |  |
| 16 | 3.1 | **Requirements Document** |  | 5d | 2013-08-28 | 2013-09-03 |  | 1d |  |  | 68h | {806C1411-175A-43FA-9F9A-5F11107A2A03} | Project Scope Management |  |  |
| 17 | 3.1.1 | Conduct Planning Workshop |  | 1d | 2013-08-28 | 2013-08-28 | 14 | 1d | 0d | Project Director | 8h | {88FBBAD4-74EB-40D1-857C-8A23FA81CC48} | Project Scope Management | Delivery Approach, Meeting Minutes, Action Items | Delivery Approach, Meeting Minutes, Action Items |
| 18 | 3.1.2 | Collect Project Requirements |  | 1d | 2013-08-29 | 2013-08-29 | 17 | 1d | 0d | Application Architect; Technical Architect; Project Manager | 12h | {D072F9A2-5434-4845-9258-DB2700A7E5E8} | Project Scope Management | Requirements worksheets | Requirements worksheets |
| 19 | 3.1.3 | Develop Requirements Management Plan |  | 1d | 2013-08-30 | 2013-08-30 | 18 | 1d | 0d | Project Director | 8h |  | Project Scope Management | Requirements Management Plan | Requirements Management Plan |
| 20 | 3.1.4 | Develop Requirements Traceability Matrix |  | 1d | 2013-08-30 | 2013-08-30 | 18 | 1d | 0d | Application Architect; Technical Architect; Project Manager | 24h |  | Project Scope Management | Requirements Traceability Matrix | Requirements Traceability Matrix |
| 21 | 3.1.5 | Produce Requirements Document |  | 1d | 2013-09-03 | 2013-09-03 | 18, 19, 20 | 1d | 0d | Project Manager; Acceptor | 16h | {EA95361D-14D5-41DB-9FAE-49AC741D4C1F} | Project Scope Management | Project Requirements Document | Project Requirements Document |
| 22 | 3.1.6 | Requirements Documentation Complete | milestone | 0d | 2013-09-03 | 2013-09-03 | 21 | 1d | 0d |  |  |  | Project Scope Management |  |  |
| 23 | 3.2 | **Project Scope Statement** |  | 7d | 2013-09-04 | 2013-09-12 |  | 1d |  |  | 56h | {95DE3CDA-9499-4744-AD39-564285641A52} | Project Scope Management |  |  |
| 24 | 3.2.1 | Document Scope Management Plan |  | 1d | 2013-09-05 | 2013-09-05 | 14 | 5d | 4d | Project Manager | 8h | {D41357CE-3064-4703-9848-363B05EAE0EC} | Project Scope Management | Scope Management Plan | Scope Management Plan |
| 25 | 3.2.2 | Define Project Scope |  | 1d | 2013-09-04 | 2013-09-04 | 22 | 1d | 0d | Project Manager | 8h | {7D578EAF-E191-4444-AB3A-7F8B89F05489} | Project Scope Management | Definition of Project Scope | Definition of Project Scope |
| 26 | 3.2.3 | Specify Deliverables and Acceptance Criteria |  | 1d | 2013-09-06 | 2013-09-06 | 25 | 4d | 3d | Project Manager | 8h | {4114A4DD-975E-4B82-AA9E-A494E75E7AA9} | Project Scope Management | Deliverable Specifications | Deliverable Specifications |
| 27 | 3.2.4 | Identify Project Exclusions |  | 1d | 2013-09-09 | 2013-09-09 | 25 | 3d | 2d | Project Manager | 8h |  | Project Scope Management | Project Exclusions | Project Exclusions |
| 28 | 3.2.5 | Document Assumptions and Constraints |  | 1d | 2013-09-10 | 2013-09-10 | 25 | 2d | 1d | Project Manager | 8h | {EF914BD9-AA5A-4684-BC54-11DDA9EFF8B6} | Project Scope Management | List of Assumptions | List of Assumptions |
| 29 | 3.2.6 | Update Requirements Traceability Matrix |  | 1d | 2013-09-11 | 2013-09-11 | 25 | 1d | 0d | Project Manager | 8h |  | Project Scope Management | Requirements Traceability Matrix | Requirements Traceability Matrix |
| 30 | 3.2.7 | Document Project Scope |  | 1d | 2013-09-12 | 2013-09-12 | 24, 25, 26, 27, 28, 29 | 1d | 0d | Project Manager | 8h |  | Project Scope Management | Project Scope | Project Scope |
| 31 | 3.2.8 | Scope Complete | milestone | 0d | 2013-09-12 | 2013-09-12 | 30 | 1d | 0d |  |  |  | Project Scope Management |  |  |

Notes:
- 2: The Initiating Stage does the preliminary analysis to define the project objectives and ensures that further project work is authorized.
- 3: Identify all the people and organizations impacted by the project and document the information regarding their interests, involvement, and impact on the project's success.
- 4: Identify all possible project stakeholders, and any relevant information such as their role, department, interests, and expectations.
- 5: Identify the possible impact each stakeholder could have on the project and classify each stakeholder based on power, interest, influence, impact and decision making.
- 6: Generate the Stakeholder Register documenting the results of this activity.
- 7: Milestone to record the completion of the Identify Stakeholders activity group
- 8: The Project Charter is developed to formally authorize a project. The Project Charter contains the high level definition of the project and the business justification for the project.
- 9: Define the primary goals and objectives for the project.
- 10: Understand the business organization and its personnel and formulate high level strategies and plans to ensure achievement of objectives.
- 11: Research previous experience with similar projects and with similar technologies and obtain sample materials.
- 12: Develop the Project Charter and present it for approval to proceed with the project.
- 13: Milestone to reflect the completion of the Develop Project Charter Activity
- 14: Milestone to reflect the completion of the Initiating Phase
- 15: The Planning Stage defines the necessary steps to ensure that proper planning is done, during project start-up, before each new phase starts and as part of the change management process
- 16: The preliminary steps necessary to develop the project's goals and objectives and secure commitment to continue the project.
- 17: Conduct an internal planning session to think through all elements of the project, identify the critical success factors, and map out the project approach.
- 18: Conduct Interviews, focus groups, facilitated workshops, group processes, questionnaires, and observations to collect the requirements for the project
- 19: Document how the requirements will be analyzed, documented and managed throughout the project.
- 20: Initial development of the Requirements Traceability Matrix (RTM). The RTM is a living document that will evolve as the project evolves the requirements and test scenarios and cases are developed.
- 21: Consolidate the requirements into the Requirements Document.
- 22: Milestone to reflect the completion of the Collection of the Project Requirements
- 23: Establish the Project Scope, WBS and Deliverables necessary to ensure that the objectives defined in the Project Charter are met.
- 24: The Scope Management Plan defines the degree of rigor to be applied to the project based on it's size, complexity, risk tolerance and organizational importance.
- 25: Establish and maintain a common understanding with the customer of the scope of the project.
- 26: Create a clear and unambiguous definition of each deliverable in terms of format, size and quality requirements, and specify the acceptance procedures and acceptance criteria for each deliverable.
- 27: The capture, reporting and acceptance of project exclusions help to clarify the scope by clearly articulating components that will not be delivered by the project.
- 28: Maintain an ongoing list of the assumptions and constraints on which the estimates and schedules are based.
- 29: Update the Requirements Traceability Matrix with additional requirements identified during project scoping.
- 30: Consolidate all project scope interim deliverables into the Project Scope Document
- 31: Milestone to reflect the completion of the Project Scope

| ID | WBS | Task | Type | Duration | Start | Finish | Predecessors | Total slack | Free slack | Resources | Work | PMBOK Knowledge Area | Deliverables | Text7 | Text8 |
| --- | --- | --- | --- | --- | --- | --- | --- | --- | --- | --- | --- | --- | --- | --- | --- |
| 32 | 3.3 | **Work Breakdown Structure and WBS Dictionary** |  | 6d | 2013-09-16 | 2013-09-23 |  | 2d |  |  | 16h | Project Scope Management |  |  |  |
| 33 | 3.3.1 | Build Project WBS |  | 1d | 2013-09-16 | 2013-09-16 | 31 | 2d | 0d | Project Manager | 8h | Project Scope Management | Detailed Work Breakdown Structure | Detailed Work Breakdown Structure | {4CE8F49D-3B1C-499D-B443-D92332BF0DAF} |
| 34 | 3.3.2 | Develop WBS Dictionary |  | 1d | 2013-09-23 | 2013-09-23 | 33 | 2d | 0d | Project Manager | 8h | Project Scope Management | Work Breakdown Structure Dictionary | Work Breakdown Structure Dictionary |  |
| 35 | 3.3.3 | WBS Complete | milestone | 0d | 2013-09-23 | 2013-09-23 | 34 | 9d |  |  |  | Project Scope Management |  |  |  |
| 36 | 3.4 | **Project Schedule** |  | 8d | 2013-09-13 | 2013-09-24 |  | 3d |  |  | 48h | Project Time Management |  |  | {9A5B5224-9460-4935-B3A7-009C062DADB7} |
| 37 | 3.4.1 | Document Schedule Management Plan |  | 1d | 2013-09-13 | 2013-09-13 | 14 | 3d | 1d | Project Manager | 8h | Project Time Management | Schedule Management Plan | Schedule Management Plan |  |
| 38 | 3.4.2 | Define Project Activities |  | 1d | 2013-09-17 | 2013-09-17 | 33, 37 | 2d | 0d | Project Manager | 8h | Project Time Management | Activity List | Activity List |  |
| 39 | 3.4.3 | Sequence Project Activities |  | 1d | 2013-09-19 | 2013-09-19 | 38 | 2d | 1d | Project Manager | 8h | Project Time Management | Project Schedule Network Diagrams | Project Schedule Network Diagrams |  |
| 40 | 3.4.4 | Estimate Activity Resources |  | 1d | 2013-09-18 | 2013-09-18 | 38 | 2d | 0d | Project Manager | 8h | Project Time Management | Resource Requirements | Resource Requirements | {06465EA9-B9D4-4FC6-90E9-BB1754698FB0} |
| 41 | 3.4.5 | Estimate Activity Durations |  | 1d | 2013-09-20 | 2013-09-20 | 38, 40 | 1d | 0d | Project Manager | 8h | Project Time Management | Activity Duration Estimates | Activity Duration Estimates | {1F882724-D99F-42E3-914F-9A8BBBF26DAF} |
| 42 | 3.4.6 | Develop Project Schedule |  | 1d | 2013-09-24 | 2013-09-24 | 39, 40, 41 | 1d | 0d | Project Manager | 8h | Project Time Management | Project Schedules | Project Schedules | {34630974-5E1A-4627-BF7C-C27ECB7BA7D0} |
| 43 | 3.4.7 | Project Schedule Complete | milestone | 0d | 2013-09-24 | 2013-09-24 | 42 | 8d |  |  |  | Project Time Management |  |  |  |
| 44 | 3.5 | **Project Budget** |  | 21d | 2013-08-29 | 2013-09-26 |  | 1d |  |  | 24h | Project Cost Management |  |  |  |
| 45 | 3.5.1 | Document Cost Management Plan |  | 1d | 2013-08-29 | 2013-08-29 | 14 | 19d | 18d | Project Director | 8h | Project Cost Management | Cost Management Plan | Cost Management Plan |  |
| 46 | 3.5.2 | Estimate Project Costs |  | 1d | 2013-09-25 | 2013-09-25 | 30, 33, 34, 42, 45, 53 | 1d | 0d | Project Manager | 8h | Project Cost Management | Cost Estimates | Cost Estimates |  |
| 47 | 3.5.3 | Determine Project Budget |  | 1d | 2013-09-26 | 2013-09-26 | 46 | 1d | 0d | Project Director | 8h | Project Cost Management | Cost Baseline | Cost Baseline |  |
| 48 | 3.5.4 | Project Budget Complete | milestone | 0d | 2013-09-26 | 2013-09-26 | 47 | 1d | 0d |  |  | Project Cost Management |  |  |  |
| 49 | 3.6 | **Quality Plan** |  | 1d | 2013-09-27 | 2013-09-27 |  | 1d |  |  | 16h | Project Quality Management |  |  | {876CD06D-940E-43EF-9802-509E60EAB5CE} |
| 50 | 3.6.1 | Plan Project Quality |  | 1d | 2013-09-27 | 2013-09-27 | 48 | 1d | 0d | Quality Assurance Manager; Acceptor | 16h | Project Quality Management | Quality Management Plan | Quality Management Plan | {7EA7295C-E263-460F-90CF-04B701A84D0C} |
| 51 | 3.6.2 | Quality Plan Complete | milestone | 0d | 2013-09-27 | 2013-09-27 | 50 | 5d |  |  |  | Project Quality Management |  |  |  |
| 52 | 3.7 | **Human Resource Plan** |  | 1d | 2013-09-19 | 2013-09-19 |  | 4d |  |  | 8h | Project Human Resource Management |  |  | {6408A32D-C81E-401C-979E-415CC873B042} |
| 53 | 3.7.1 | Develop Human Resource Plan |  | 1d | 2013-09-19 | 2013-09-19 | 40 | 4d | 0d | Project Director | 8h | Project Human Resource Management | Human Resource Management Plan | Human Resource Management Plan | {97CEC677-51C8-4BC5-8123-0FB0443D19E6} |
| 54 | 3.7.2 | Human Resource Plan Complete | milestone | 0d | 2013-09-19 | 2013-09-19 | 53 | 11d |  |  |  | Project Human Resource Management |  |  |  |
| 55 | 3.8 | **Communications Plan** |  | 1d | 2013-08-29 | 2013-08-29 |  |  |  |  | 16h | Project Communications Management |  |  | {876CD06D-940E-43EF-9802-509E60EAB5CE} |
| 56 | 3.8.1 | Plan Project Communications |  | 1d | 2013-09-02 | 2013-09-02 | 14 | -2d | 0d | Project Manager; Acceptor | 16h | Project Communications Management | Communications Management Plan | Communications Management Plan | {EDAC4ED9-D4A4-41E9-8663-0C10D94137D2} |
| 57 | 3.8.2 | Communications Plan Complete | milestone | 0d | 2013-09-02 | 2013-09-02 | 56 | -2d | 0d |  |  | Project Communications Management |  |  |  |

Notes:
- 32: The Work Breakdown Structure (WBS) is the subdivision of the project deliverables and work into smaller, more manageable components.
- 33: Develop the project structure in terms of detailed phases, activities, tasks, deliverables, and resources using a process called task decomposition.
- 34: The WBS Dictionary provided detailed descriptions of the components of the WBS.
- 35: Milestone to reflect the completion of the Project WBS
- 36: Identify and assign project resources, determine project activity and task dependencies, develop task estimates develop the project schedule.
- 37: The Schedule Management Plan defines the processes to be followed to maintain the project's schedule. This will include the timeline for collecting project timesheets, validating estimates to complete and updating the project schedule
- 38: Identify the specific actions to be performed to produce the project deliverables.
- 39: Identify the dependencies between the work components (the network logic).
- 40: Identify resources (human and other) that will be required to successfully deliver the project
- 41: Produce a detailed estimates of the costs and material resources required to deliver each component of the Work Breakdown Structure.
- 42: Define the milestones and phase dates for each component of the Work Breakdown Structure, and identify the dependencies between the work components (the network logic).
- 43: Milestone to reflect the completion of the Project Schedule
- 44: Develop the project budget to identify all costs associated with delivering the project.
- 45: The Cost Management Plan defines the approach for defining and managing the project's budget taking into account accounting standards and processes in the organization.
- 46: Develop the costs needed to complete all project activities, including human, material, equipment and all other costs associated with completing each project activity. Project costs include Risk Reserve and Cost of Quality (COQ) allocations
- 47: Aggregate the activity costs to develop the overall project budget. Translate the estimates and schedule into an expected monthly cash flow as the basis for monitoring the project's financial performance.
- 48: Milestone to reflect the completion of the Project Budget
- 49: Prepare the way for a quality project.
- 50: Establish the baseline against which project quality will be measured and describe the methods and procedures to be used for monitoring and verifying project quality.
- 51: Milestone to reflect the completion of the Quality Plan
- 52: Identify and mobilize a productive and motivated project team.
- 53: Create an effective and efficient project organization structure, including roles and responsibilities, org charts and staffing plans.
- 54: Milestone to reflect the completion of the Human Resource Plan
- 55: Develop the process for ensuring effective and efficient communication to address all stakeholder's information needs and requirements
- 56: Describe the methods and procedures to be used to identify and document the project communications requirements.
- 57: Milestone to reflect the completion of the Quality Plan

| ID | WBS | Task | Type | Duration | Start | Finish | Predecessors | Total slack | Free slack | Resources | Work | PMBOK Knowledge Area | Text8 |
| --- | --- | --- | --- | --- | --- | --- | --- | --- | --- | --- | --- | --- | --- |
| 58 | 3.9 | **Risk Management Plan** |  | 27d | 2013-08-28 | 2013-10-03 |  | 1d |  |  | 48h | Project Risk Management | {66511070-9C49-422A-8846-9AC465BD0C01} |
| 59 | 3.9.1 | Plan Risk Management |  | 1d | 2013-08-28 | 2013-08-28 | 14 | 23d | 22d | Project Manager; Acceptor | 16h | Project Risk Management | {45EDBAF3-1B1B-47AB-BA9A-16AA807904AD} |
| 60 | 3.9.2 | Identify Project Risks |  | 1d | 2013-09-30 | 2013-09-30 | 21, 30, 33, 42, 47, 50, 53, 59 | 1d | 0d | Project Manager | 8h | Project Risk Management | {EBAE1915-9562-4244-9B40-2BA3EE473D61} |
| 61 | 3.9.3 | Perform Qualitative Risk Analysis |  | 1d | 2013-10-01 | 2013-10-01 | 60 | 2d | 1d | Project Manager | 8h | Project Risk Management | {77A32E65-9594-48CD-AA3C-65C2B8F1F200} |
| 62 | 3.9.4 | Perform Quantitative Risk Analysis |  | 1d | 2013-10-02 | 2013-10-02 | 60 | 1d | 0d | Project Manager | 8h | Project Risk Management | {77A32E65-9594-48CD-AA3C-65C2B8F1F200} |
| 63 | 3.9.5 | Plan Risk Responses |  | 1d | 2013-10-03 | 2013-10-03 | 61, 62 | 1d | 0d | Project Manager | 8h | Project Risk Management |  |
| 64 | 3.9.6 | Risk Plan Complete | milestone | 0d | 2013-10-03 | 2013-10-03 | 63 | 1d |  |  |  | Project Risk Management |  |
| 65 | 3.10 | **Procurement Plan** |  | 1d | 2013-09-27 | 2013-09-27 |  | 30d |  |  | 8h | Project Procurement Management | {AA3830EA-4325-44FB-861C-5C8A094E9175} |
| 66 | 3.10.1 | Plan Project Procurements |  | 1d | 2013-09-27 | 2013-09-27 | 21, 33, 42, 47 | 30d | 0d | Contracts Manager | 8h | Project Procurement Management | {19216447-5E1B-4DD5-8623-550C25FB6677} |
| 67 | 3.10.2 | Procurement Plan Complete | milestone | 0d | 2013-09-27 | 2013-09-27 | 66 | 30d | 11d |  |  | Project Procurement Management |  |
| 68 | 3.11 | **Stakeholder Management Plan** |  | 1d | 2013-09-26 | 2013-09-26 |  | 12d |  |  | 8h | Project Stakeholder Management |  |
| 69 | 3.11.1 | Plan Stakeholder Management |  | 1d | 2013-09-26 | 2013-09-26 | 14 | 12d | 0d | Project Manager | 8h | Project Stakeholder Management |  |
| 70 | 3.11.2 | Stakeholder Management Plan Complete | milestone | 0d | 2013-09-26 | 2013-09-26 | 69 | 12d |  |  |  | Project Stakeholder Management |  |
| 71 | 3.12 | **Project Management Plan** |  | 1d | 2013-10-07 | 2013-10-07 |  |  |  |  | 16h | Project Integration Management | {D77316F4-6F61-48D6-A108-0CB54363FC11} |
| 72 | 3.12.1 | Document Project Management Plan |  | 1d | 2013-10-07 | 2013-10-07 | 22, 31, 35, 43, 48, 51, 54, 57, 64 | 0d |  | Project Manager; Acceptor | 16h | Project Integration Management | {108CFA76-ADCF-4F36-8E6A-67B9F0D976F8} |
| 73 | 3.12.2 | Project Management Plan Complete | milestone | 0d | 2013-10-07 | 2013-10-07 | 72 | 0d |  |  |  | Project Integration Management |  |
| 74 | 3.13 | **Project Support Plans** |  | 2d | 2013-10-08 | 2013-10-09 |  |  |  |  | 32h | Project Integration Management | {9C39696B-89FF-49DD-9F69-2FB373683783} |
| 75 | 3.13.1 | Document Configuration Management Plan |  | 1d | 2013-10-08 | 2013-10-08 | 73 | 1d |  | Project Manager; Acceptor | 16h | Project Integration Management | {758AA896-CC85-4B63-B379-5F4D3E3D35D9} |
| 76 | 3.13.2 | Document Data Management Plan |  | 1d | 2013-10-09 | 2013-10-09 | 73 | 0d |  | Project Manager; Acceptor | 16h | Project Integration Management | {AF9D19DB-E8C4-48A0-ABE4-0F301E47F314} |
| 77 | 3.14 | **Project Environment** |  | 5d | 2013-10-08 | 2013-10-14 |  | 0d |  |  | 32h | Project Integration Management | {2FAC9CBC-F47B-4EDC-9C65-6D8FCADD1824} |
| 78 | 3.14.1 | Prepare Project Facilities |  | 1d | 2013-10-10 | 2013-10-10 | 73 | 2d |  | Project Manager | 8h | Project Integration Management | {53CB9D49-853C-4DF7-937F-2EEBA2112926} |
| 79 | 3.14.2 | Set Up Project Standards and Procedures |  | 1d | 2013-10-08 | 2013-10-08 | 73 | 4d |  | Quality Assurance Manager | 8h | Project Integration Management | {98F8B241-19C7-4119-9A9C-BB7C740C0FD6} |
| 80 | 3.14.3 | Set Up Project Management Tools |  | 1d | 2013-10-11 | 2013-10-11 | 73 | 1d |  | Project Manager | 8h | Project Integration Management | {F3DD8690-6056-4E5E-9497-8052A93A2321} |
| 81 | 3.14.4 | Set Up Project Book |  | 1d | 2013-10-14 | 2013-10-14 | 73 | 0d |  | Project Manager | 8h | Project Integration Management | {1246E423-0006-4FDF-834B-8943AEC48ABB} |
| 82 | 3.15 | Planning Complete | milestone | 0d | 2013-10-14 | 2013-10-14 | 70, 73, 75, 76, 78, 79, 80, 81 | 0d |  |  |  |  |  |

Notes:
- 58: Identify, analyze and profile project risks.
- 59: Describe the methods and procedures to be used to identify, evaluate, and eliminate or minimize project risks based on the project's risk profile / Deliverables: Risk Management Plan / Text7: Risk Management Plan
- 60: Risk identification identifies the risks which if unmanaged could impact the project. / Deliverables: Risk Register / Text7: Risk Register
- 61: Conduct a comprehensive Qualitative Analysis of a project's risks and impacts. The result is a prioritized list of risks. / Deliverables: Risk Register / Text7: Risk Register
- 62: Perform a comprehensive Quantitative Analysis of a project's risks and impacts. The result is a prioritized list of risks. / Deliverables: Risk Register / Text7: Risk Register
- 63: Develop plans to address identified risks / Deliverables: Risk Management Action Plan, Risk Register / Text7: Risk Management Action Plan, Risk Register
- 64: Milestone to reflect the completion of the Risk Plan
- 65: To understand and document what needs to be purchased/contracted for the project and how the purchasing/contracting is to be done.
- 66: To understand which project components will be delivered with in-house resources and which will have to be procured from outside vendors/suppliers / Deliverables: Procurement Management Plan, Procurement Statement(s) of Work / Text7: Procurement Management Plan, Procurement Statement(s) of Work
- 67: Milestone to reflect the completion of the Procurement Plan
- 68: Develop appropriate management strategies to effectively engage stakeholders throughout the project lifecycle.
- 69: Analyze the stakeholder's needs, interested and potential impact on the project's success and develop strategies for satisfying their needs / Deliverables: Stakeholder Management Plan / Text7: Stakeholder Management Plan
- 70: Milestone to reflect the completion of the Stakeholder Management Plan
- 71: The Project Management Plan contains the results of the Project Planning Phase and provides the definition against which the project will be delivered.
- 72: Establish the baseline for scope, budget, schedule, and quality, against which project performance is measured and all changes to the project are controlled. / Deliverables: Project Management Plan / Text7: Project Management Plan
- 73: Milestone to reflect the completion of the overall Project Management Plan
- 74: Document the Risk, Configuration and Data Management Plans which will be used to define these aspects of the project delivery approach.
- 75: Describe the methods and procedures to be used to establish effective identification, control, accounting, and auditing of controlled items throughout the development life cycle. / Deliverables: Configuration Management Plan / Text7: Configuration Management Plan
- 76: Describe the methods and procedures to be used to implement and maintain a Data Management System for the identification, acquisition, distribution, delivery, and status reporting of data. / Deliverables: Data Management Plan / Text7: Data Management Plan
- 77: Ensure that the fundamental project delivery infrastructure is in place (e.g., work space, standards and procedures, project tools).
- 78: Obtain and furnish work space with the appropriate facilities. / Deliverables: Physical Project Environment / Text7: Physical Project Environment
- 79: Define and document the specific standards and procedures to be applied on the project to ensure consistent delivery in accordance with the quality requirements. / Deliverables: Project Standards and Procedures / Text7: Project Standards and Procedures
- 80: Implement the project management tools to be used by the project team to manage performance. / Deliverables: Project Management Tools / Text7: Project Management Tools
- 81: Collect and store the project's quality and scope control records in a standard, single location to provide familiar, rapid access to key project management information. / Deliverables: Project Book / Text7: Project Book
- 82: Milestone to reflect the completion of the Project Planning phase and obtainment of formal approval to proceed to deliver the project

| ID | WBS | Task | Duration | Start | Finish | Predecessors | Total slack | Resources | Work | Text8 | PMBOK Knowledge Area | Deliverables | Text7 |
| --- | --- | --- | --- | --- | --- | --- | --- | --- | --- | --- | --- | --- | --- |
| 83 | 4 | **Executing** | 23d | 2013-10-15 | 2013-11-14 |  | 0d |  | 192h | {50B2FF1C-BDE3-4BEA-98E4-CFFCF300640C} |  |  |  |
| 84 | 4.1 | **Project Work Authorization Forms** | 7d | 2013-10-15 | 2013-10-23 |  | 16d |  | 32h | {AF0DA97D-C86A-4941-91B4-60AB63A140C0} | Project Integration Management |  |  |
| 85 | 4.1.1 | Authorize Work Packages | 1d | 2013-10-15 | 2013-10-15 | 82 | 22d | Team Leader | 8h | {FDD2B86C-3483-49A8-8DF9-6D14ABF67830} | Project Integration Management | Work Authorization Form | Work Authorization Form |
| 86 | 4.1.2 | Manage Process Data | 1d | 2013-10-21 | 2013-10-21 | 82 | 18d | Project Manager | 8h | {45E0B4FF-03F0-49C8-B8C5-3AD058E55863} | Project Integration Management | Project Information System | Project Information System |
| 87 | 4.1.3 | Provide General Office Support | 1d | 2013-10-22 | 2013-10-22 | 82 | 17d | Project Manager | 8h | {54D324D0-FE8A-4217-9E66-CED1A53EA9C2} | Project Integration Management | General Office Support | General Office Support |
| 88 | 4.1.4 | Administer Project Security Processes | 1d | 2013-10-23 | 2013-10-23 | 82 | 16d | Project Manager | 8h | {EA419DF1-FDD9-4BE1-9C15-AD4966E400AA} | Project Integration Management | Security Administration | Security Administration |
| 89 | 4.2 | **Quality Assurance Audits** | 4d | 2013-10-15 | 2013-10-18 |  | 19d |  | 32h | {2154DB83-EEDD-48FB-A6ED-3E300450A22F} | Project Quality Management |  |  |
| 90 | 4.2.1 | Participate in Walk-throughs and Reviews | 1d | 2013-10-15 | 2013-10-15 | 82 | 22d | Quality Assurance Manager | 8h | {EC1F03E5-B62E-48B9-BCD1-E469A76634D9} | Project Quality Management | Walk-through/Review Reports, Action Items | Walk-through/Review Reports, Action Items |
| 91 | 4.2.2 | Conduct Inspections and Audits | 1d | 2013-10-16 | 2013-10-16 | 82 | 21d | Quality Assurance Manager | 8h | {A0E69615-2E15-4860-9FA6-F594F8C864BA} | Project Quality Management | Inspection and Audit Reports, Action Items | Inspection and Audit Reports, Action Items |
| 92 | 4.2.3 | Conduct Project Reviews | 1d | 2013-10-17 | 2013-10-17 | 82 | 20d | Quality Assurance Manager | 8h | {C98ABD87-BE39-4265-A6FF-59A39970BCBE} | Project Quality Management | Project Review, Action Items | Project Review, Action Items |
| 93 | 4.2.4 | Facilitate Continuous Improvement | 1d | 2013-10-18 | 2013-10-18 | 82 | 19d | Quality Assurance Manager | 8h | {560D794D-167B-475C-9083-98315634E86A} | Project Quality Management | Corrective Action Request | Corrective Action Request |
| 94 | 4.3 | **Project Team Orientation** | 4d | 2013-10-15 | 2013-10-18 |  | 0d |  | 24h | {B5045677-A161-4471-A0C5-B37CD56D1D21} | Project Human Resource Management |  |  |
| 95 | 4.3.1 | Obtain Required Resources | 1d | 2013-10-15 | 2013-10-15 | 54, 82 | 0d | Project Director | 8h | {13795CE5-FC73-448D-AEE8-9943C393E4CA} | Project Human Resource Management | Staff Rotation Plan, Action Items, Project Team Directory | Staff Rotation Plan, Action Items, Project Team Directory |
| 96 | 4.3.2 | Conduct Team Orientation | 1d | 2013-10-16 | 2013-10-16 | 95 | 0d | Project Director | 8h | {BFEE75D5-B45F-4C51-A7E9-CE03662BA5DA} | Project Human Resource Management | Orientation Package | Orientation Package |
| 97 | 4.3.3 | Assign Individual Responsibilities | 1d | 2013-10-18 | 2013-10-18 | 96 | 0d | Team Leader | 8h | {4FA97D1F-F1C3-43F1-9F74-E376A6152C9E} | Project Human Resource Management | Project and Personal Objectives | Project and Personal Objectives |
| 98 | 4.4 | **Team Training and Execution** | 12d | 2013-10-25 | 2013-11-11 |  | 3d |  | 16h | {E190E569-16F6-4726-AF14-A343767ED0BA} | Project Human Resource Management |  |  |
| 99 | 4.4.1 | Provide Team Training | 1d | 2013-11-11 | 2013-11-11 | 97 | 3d | Project Manager | 8h | {76C96CBB-2FF2-458A-B388-E01BFF1ED940} | Project Human Resource Management | Training Needs Analysis | Training Needs Analysis |
| 100 | 4.4.2 | Recognize Individual and Team Success | 1d | 2013-10-25 | 2013-10-25 | 97 | 14d | Project Director | 8h | {B5A8299A-BDB1-442D-90A5-66F1C0A77859} | Project Human Resource Management | Recognition Programs | Recognition Programs |
| 101 | 4.5 | **Project Team Appraisals and Staff Rotations** | 19d | 2013-10-21 | 2013-11-14 |  | 0d |  | 40h | {E190E569-16F6-4726-AF14-A343767ED0BA} | Project Human Resource Management |  |  |
| 102 | 4.5.1 | Conduct Performance Appraisals | 1d | 2013-11-12 | 2013-11-12 | 97 | 2d | Project Manager | 8h | {76C96CBB-2FF2-458A-B388-E01BFF1ED940} | Project Human Resource Management | Performance Appraisals | Performance Appraisals |
| 103 | 4.5.2 | Manage Staffing Changes | 1d | 2013-10-28 | 2013-10-28 | 97 | 13d | Project Director | 8h | {B5A8299A-BDB1-442D-90A5-66F1C0A77859} | Project Human Resource Management | Organization Structure | Organization Structure |
| 104 | 4.5.3 | Manage Team Communications | 1d | 2013-11-13 | 2013-11-13 | 97 | 1d | Project Manager | 8h | {B11868D1-04E1-49A3-88C4-97EB120CB3F9} | Project Human Resource Management | Project Communications | Project Communications |
| 105 | 4.5.4 | Meet With Team | 1d | 2013-10-21 | 2013-10-21 | 97 | 18d | Team Leader | 8h | {F16DA7CE-DCD6-44D4-9285-46412B60BBBE} | Project Human Resource Management | Meeting Minutes | Meeting Minutes |
| 106 | 4.5.5 | Monitor Team Morale | 1d | 2013-11-14 | 2013-11-14 | 97 | 0d | Project Manager | 8h | {02C8777F-A20F-48AC-B123-78A1BA3DFE3F} | Project Human Resource Management | Team Surveys | Team Surveys |

Notes:
- 83: Coordinating the people and other resources required to deliver the project
- 84: Manage the data that supports the project and implement the discipline of configuration management.
- 85: Delegate delivery responsibilities for a work package, establish a clear and unambiguous understanding for how the work package is to be delivered, witness commitment, and formally authorize the commencement of work.
- 86: Collect and maintain the project's work performance data on the project's processes, metrics, and lessons learned.
- 87: Provide general office support such as producing correspondence, document production and distribution services, and maintaining files and logs.
- 88: Design and implement procedures to ensure adequate project security, including such things as badges, sign-in registers, electronic lock accessibility, and monitoring the security related practices in all project facilities.
- 89: Monitor the levels of quality being achieved.
- 90: Participate in structured walk-throughs and reviews of project deliverables with members of the project team, to represent quality concerns.
- 91: Conduct inspections and audits to determine the completeness and consistency of processes and deliverables.
- 92: Review and appraise the project to assess and increase the probability of project success.
- 93: Investigate the causes of problems and analyze work operations to identify process improvements and reduce or eliminate failures.
- 94: Assemble, deliver team orientation and assign project responsibilities
- 95: Negotiate for resources and prepare action plans to identify any staffing deficiencies.
- 96: Provide a formal orientation to the project and build a common understanding within the team.
- 97: Delegate responsibility for work assignments and witness commitment.
- 98: Optimize the performance of team members in achieving project goals.
- 99: Provide training to members of the project team (including business and subcontractor personnel) in the project-specific methodology, tools, or technology, as required.
- 100: Develop and implement means to recognize and reward quality service, creativity, innovation, and success.
- 101: Optimize the performance of team members in achieving project goals.
- 102: Provide training to members of the project team (including business and subcontractor personnel) in the project-specific methodology, tools, or technology, as required.
- 103: Execute staff rotation plan and other adhoc staff changes as required based on performance and other project changes.
- 104: Develop and implement effective communications among all members of the project team.
- 105: Meet regularly with team members to review status, share experiences, provide suggestions, and resolve problems and concerns.
- 106: Monitor team morale and take action to correct problem areas.

| ID | WBS | Task | Type | Duration | Start | Finish | Predecessors | Total slack | Free slack | Resources | Work | PMBOK Knowledge Area | Text8 |
| --- | --- | --- | --- | --- | --- | --- | --- | --- | --- | --- | --- | --- | --- |
| 107 | 4.6 | **Project Communications** |  | 1d | 2013-10-18 | 2013-10-18 |  | 19d |  |  | 8h | Project Communications Management |  |
| 108 | 4.6.1 | Distribute Status and Related Project Information |  | 1d | 2013-10-18 | 2013-10-18 | 82 | 19d |  | Project Director | 8h | Project Communications Management | {ACE5CF29-C935-43A0-B8C9-DCD02F869ED1} |
| 109 | 4.7 | **Subcontractor Contracts** |  | 3d | 2013-10-15 | 2013-10-17 |  | 19d |  |  | 24h | Project Procurement Management | {A8593438-D68B-453C-A227-AF20DB8AB162} |
| 110 | 4.7.1 | Issue Requisition Documents |  | 1d | 2013-10-15 | 2013-10-15 | 67, 82 | 19d | 0d | Contracts Manager | 8h | Project Procurement Management | {136901DF-52A6-4CEA-AB59-37BA92576FE4} |
| 111 | 4.7.2 | Evaluate RFP Responses |  | 1d | 2013-10-16 | 2013-10-16 | 110 | 19d | 0d | Contracts Manager | 8h | Project Procurement Management | {3DD0A7F3-8BC0-44ED-8C51-E833D236EB4F} |
| 112 | 4.7.3 | Negotiate Subcontractor Contract |  | 1d | 2013-10-17 | 2013-10-17 | 111 | 19d | 0d | Contracts Manager | 8h | Project Procurement Management | {D1675402-649B-4747-9CC6-2D76770FD82F} |
| 113 | 4.8 | **Stakeholder Engagement** |  | 6d | 2013-10-17 | 2013-10-24 |  | 15d |  |  | 16h | Project Stakeholder Management | {073B2DA2-ABA4-42F5-9783-5CAFAFFDAD5E} |
| 114 | 4.8.1 | Manage Stakeholder Engagement |  | 1d | 2013-10-17 | 2013-10-17 | 82 | 15d | 0d | Project Director | 8h | Project Stakeholder Management |  |
| 115 | 4.8.2 | Resolve Stakeholder Issues and Concerns |  | 1d | 2013-10-24 | 2013-10-24 | 114 | 15d |  | Project Director | 8h | Project Stakeholder Management | {8C1DB233-8A93-48F2-9A10-8DBB6529E1F5} |
| 116 | 4.9 | Executing Complete | milestone | 0d | 2013-11-14 | 2013-11-14 | 85, 86, 87, 88, 90, 91, 92, 93, 95, 96, 97, 99, 100, 102, 103, 104, 105, 106, 108, 110, 111, 112, 114, 115 | 0d |  |  |  |  |  |
| 117 | 5 | **Monitoring and Controlling** |  | 19d | 2013-10-15 | 2013-11-08 |  | 4d |  |  | 216h |  | {C382A9BF-F31D-4F3D-86F0-1F978ACEE894} |
| 118 | 5.1 | **Project Information Management System** |  | 5d | 2013-10-24 | 2013-10-30 |  | 11d |  |  | 40h | Project Integration Management | {DBF8C13D-7C89-4EEB-BB6E-46D68D7580EE} |
| 119 | 5.1.1 | Manage Action Items |  | 1d | 2013-10-24 | 2013-10-24 | 82 | 15d | 11d | Project Manager | 8h | Project Integration Management | {00C20062-9469-40C7-9252-664808A02643} |
| 120 | 5.1.2 | Manage Data Items |  | 1d | 2013-10-25 | 2013-10-25 | 82 | 14d | 10d | Project Manager | 8h | Project Integration Management | {FCD50DB1-71D8-4297-89E6-13B26F2E2366} |
| 121 | 5.1.3 | Manage Configuration Items |  | 1d | 2013-10-28 | 2013-10-28 | 82 | 13d | 9d | Project Manager | 8h | Project Integration Management | {893049EA-8B0B-4DE4-A5EA-99D0B7834CC2} |
| 122 | 5.1.4 | Manage Requirements and Scope |  | 1d | 2013-10-29 | 2013-10-29 | 82 | 12d | 8d | Project Manager | 8h | Project Integration Management | {B3B5C1AE-E074-438A-B5CE-5E6CDADC92B0} |
| 123 | 5.1.5 | Manage Project Records |  | 1d | 2013-10-30 | 2013-10-30 | 82 | 11d | 7d | Project Manager | 8h | Project Integration Management | {AC4FCBEF-352F-4D74-9FAD-15EFCB17DC66} |
| 124 | 5.2 | **Project Change Requests** |  | 2d | 2013-10-31 | 2013-11-01 |  | 9d |  |  | 16h | Project Integration Management | {F12473D0-2466-4130-970B-9AF0A167E80C} |
| 125 | 5.2.1 | Control Project Scope |  | 1d | 2013-10-31 | 2013-10-31 | 82 | 10d | 6d | Project Manager | 8h | Project Scope Management | {2AD154CE-1B6F-49E6-9562-46EE4950EDF4} |
| 126 | 5.2.2 | Control Scope Changes |  | 1d | 2013-11-01 | 2013-11-01 | 82 | 9d | 5d | Project Manager | 8h | Project Integration Management | {FCDC19B3-376E-4AB7-B16B-441774E89C3D} |
| 127 | 5.3 | **Project Acceptance Documents** |  | 1d | 2013-10-15 | 2013-10-15 |  | 22d |  |  | 16h | Project Scope Management | {F20CAECE-7B7D-4B7E-9ED9-0D9C4E969E8C} |
| 128 | 5.3.1 | Manage Project Acceptance |  | 1d | 2013-10-15 | 2013-10-15 | 82 | 22d | 18d | Project Manager; Acceptor | 16h | Project Scope Management | {E826D096-0CF7-46CE-AB30-96EFDB2BDB7F} |
| 129 | 5.4 | **Project Schedule Updates** |  | 15d | 2013-10-16 | 2013-11-05 |  | 7d |  |  | 32h | Project Time Management | {6D23781E-7A85-493E-8F5D-7C7EFBA84D2D} |
| 130 | 5.4.1 | Measure Work Performance |  | 1d | 2013-10-16 | 2013-10-16 | 82 | 21d | 17d | Team Leader; Project Manager | 16h | Project Time Management | {2C2A92E8-A3A5-4E5E-9B2E-0DAEE852B6A7} |
| 131 | 5.4.2 | Maintain Project Schedule |  | 1d | 2013-11-04 | 2013-11-04 | 82 | 8d | 4d | Project Manager | 8h | Project Time Management | {7AC731CC-5314-4268-9E0B-F29B6BABAEF2} |
| 132 | 5.4.3 | Maintain Work Plans |  | 1d | 2013-11-05 | 2013-11-05 | 82 | 7d | 3d | Project Manager | 8h | Project Time Management | {0CCACE3E-CE97-4D39-A382-0EA89BDA64FA} |

Notes:
- 107: Create, collect, distribute, store, retrieve and dispose of all project information following the processes defined in the Communications Management Plan
- 108: Maintain frequent formal and informal contact with project stakeholders to review progress and maintain open communication. / Deliverables: Project Communications, Action Items, Meeting Minutes / Text7: Project Communications, Action Items, Meeting Minutes
- 109: Selection and management of any subcontractors required to deliver the project.
- 110: Issue the formal requisition documents to prospective subcontractors. / Deliverables: Requisition Documents / Text7: Requisition Documents
- 111: Evaluate responses to the formal requisition documents from prospective subcontractors. / Deliverables: Clarification of Requisition Requirements, Bid Evaluations, Confirmation of Preferred Subcontractor, Supplier Quality Assessment / Text7: Clarification of Requisition Requirements, Bid Evaluations, Confirmation of Preferred Subcontractor, Supplier Quality Assessment
- 112: Negotiate effective contracts with subcontractors and arrange subcontract signing. / Deliverables: Non-Disclosure Agreement, Teaming Agreement, Subcontract / Text7: Non-Disclosure Agreement, Teaming Agreement, Subcontract
- 113: Develop and maintain a good working relationship with all the project stakeholders by using effective project communications.
- 114: Communication with project stakeholders to meet the identified needs and address issues as they occur. / Deliverables: Stakeholder Management Plan / Text7: Stakeholder Management Plan
- 115: Identify, track and resolve issues affecting the project. / Deliverables: Issue Resolution Request, Issue Log, Working Papers / Text7: Issue Resolution Request, Issue Log, Working Papers
- 116: Milestone to reflect the completion of project deliver
- 117: Monitoring and measuring the project performance to ensure that the project is on target (on time, on budget meeting expectations).
- 118: Monitor and control contains the project tasks which validate the overall project direction by validating that the project work is progressing according to the plan.
- 119: Record, communicate and ensure closure on all action items including changes to the contractual baseline, requirements for information, problem reports and service requests, to facilitate effective decision-making within acceptable time frames. / Deliverables: Action Item Reports / Text7: Action Item Reports
- 120: Identify, control and report upon the scheduling, publishing and release of all formal data items, and the replacement of obsolete versions, in accordance with the terms of the project plan. / Deliverables: Data Management Reports / Text7: Data Management Reports
- 121: Identify, control, and report upon selected baseline items, such as the project description, product specifications and process specifications, which formally define the project. / Deliverables: Configuration Management Reports / Text7: Configuration Management Reports
- 122: Establish and maintain a common understanding with the customer of the requirements that will be addressed by the project. / Deliverables: Baseline Traceability Matrix / Text7: Baseline Traceability Matrix
- 123: Establish, maintain, and dispose of project records in a way that provides adequate access for team members during the project and long-term retention for use in subsequent projects. / Deliverables: Project Information System, Project Book, Staffing Plan, Staff Rotation Plan, Project Team Directory, Project Index / Text7: Project Information System, Project Book, Staffing Plan, Staff Rotation Plan, Project Team Directory, Project Index
- 124: Review, approve and manage all project changes.
- 125: Establish and maintain a common understanding with the Acceptor of the scope of the project. / Deliverables: Definition of Project Scope / Text7: Definition of Project Scope
- 126: Record and obtain approval for any and every change to the approved project baselines. / Deliverables: Change Request, Change Request Log / Text7: Change Request, Change Request Log
- 127: Scope verification ensures that the project deliverables are formally accepted.
- 128: Obtain acceptance of deliverables and final sign-off that the project has been completed. / Deliverables: Acceptance Document, Acceptance Sign-off Log / Text7: Acceptance Document, Acceptance Sign-off Log
- 129: Maintaining the Project Schedule to ensure it remains accurate and current based on approved Change Requests and revised estimates to complete from Project Team Members.
- 130: Track detailed progress against each activity and task, re-assess personal commitment, and re-forecast the remaining effort to completion and the expected completion date, on a regular weekly basis. / Deliverables: Project Tracking Document / Text7: Project Tracking Document
- 131: Perform the appropriate updates to the project schedule to account for current project status, approved project changes and other project issues. / Deliverables: Project Schedules / Text7: Project Schedules
- 132: Maintain a current and reliable version of the project work plans, based on approved changes and current estimates to completion. / Deliverables: Work Plans / Text7: Work Plans

| ID | WBS | Task | Type | Duration | Start | Finish | Predecessors | Total slack | Free slack | Resources | Work | PMBOK Knowledge Area | Text8 |
| --- | --- | --- | --- | --- | --- | --- | --- | --- | --- | --- | --- | --- | --- |
| 133 | 5.5 | **Project Budget Updates** |  | 13d | 2013-10-21 | 2013-11-06 |  | 6d |  |  | 24h | Project Cost Management | {B35DD1CF-A834-4F41-825E-67EA3B8CCA71} |
| 134 | 5.5.1 | Monitor Cost/Schedule Variance |  | 1d | 2013-11-06 | 2013-11-06 | 82 | 6d | 2d | Project Manager | 8h | Project Cost Management | {6445ABBC-AA3A-49A5-BD8C-6AA9CD96A473} |
| 135 | 5.5.2 | Control Project Costs |  | 1d | 2013-10-21 | 2013-10-21 | 82 | 18d | 14d | Project Director | 8h | Project Cost Management | {D957192D-611B-43F1-B1FF-F52555C156BC} |
| 136 | 5.5.3 | Maintain Financial Plan |  | 1d | 2013-10-22 | 2013-10-22 | 82 | 17d | 13d | Project Director | 8h | Project Cost Management | {02697043-D021-4C9D-BEC0-742B2F5F3BD2} |
| 137 | 5.6 | **Quality Control Reports** |  | 3d | 2013-10-21 | 2013-10-23 |  | 16d |  |  | 24h | Project Quality Management | {01FEC875-FA8F-4984-BC4C-7E365F7FDB40} |
| 138 | 5.6.1 | Control Project Quality |  | 1d | 2013-10-21 | 2013-10-21 | 82 | 18d | 14d | Quality Assurance Manager | 8h | Project Quality Management | {5109679A-08DB-4CF2-805D-DAD88FC57095} |
| 139 | 5.6.2 | Participate in Testing |  | 1d | 2013-10-22 | 2013-10-22 | 82 | 17d | 13d | Quality Assurance Manager | 8h | Project Quality Management | {97CFFA47-E32B-4226-B645-097C1EC86790} |
| 140 | 5.6.3 | Measure Quality Levels |  | 1d | 2013-10-23 | 2013-10-23 | 82 | 16d | 12d | Quality Assurance Manager | 8h | Project Quality Management | {42F2F3BD-0768-4BF9-BA8D-EFF57847A838} |
| 141 | 5.7 | **Project Status Reports** |  | 2d | 2013-10-17 | 2013-10-18 |  | 19d |  |  | 32h | Project Communications Management | {B4E3AD0C-6057-488A-89E6-0B64C8938A04} |
| 142 | 5.7.1 | Report Weekly Status |  | 1d | 2013-10-17 | 2013-10-17 | 82 | 20d | 16d | Team Leader; Acceptor | 16h | Project Communications Management | {F11412E0-0A6B-4EA9-9A65-60D2F348A36E} |
| 143 | 5.7.2 | Report Monthly Status |  | 1d | 2013-10-18 | 2013-10-18 | 82 | 19d | 15d | Project Manager; Acceptor | 16h | Project Communications Management | {86886BAA-9A0C-4462-A3E0-EEBE20A58030} |
| 144 | 5.8 | **Project Risk Log** |  | 1d | 2013-11-07 | 2013-11-07 |  | 5d |  |  | 8h | Project Risk Management | {4FBB5A0C-B5CC-4BD0-A279-0C565EDE342C} |
| 145 | 5.8.1 | Control Project Risks |  | 1d | 2013-11-07 | 2013-11-07 | 82 | 5d | 1d | Project Manager | 8h | Project Risk Management | {A5040BE6-B725-4FE0-A0DA-81B7E6DC8C33} |
| 146 | 5.9 | **Subcontractor Status Reports** |  | 1d | 2013-10-18 | 2013-10-18 |  | 19d |  |  | 8h | Project Procurement Management | {D6AEC46D-7DB1-4270-A124-48C9EE888402} |
| 147 | 5.9.1 | Manage Subcontractor Contract |  | 1d | 2013-10-18 | 2013-10-18 | 112 | 19d | 15d | Contracts Manager | 8h | Project Procurement Management | {A8F6C42B-55BB-4E06-8D18-415DE562544C} |
| 148 | 5.10 | **Stakeholder Engagement** |  | 13d | 2013-10-23 | 2013-11-08 |  | 4d |  |  | 16h | Project Stakeholder Management |  |
| 149 | 5.10.1 | Control Project Decisions |  | 1d | 2013-11-08 | 2013-11-08 | 82 | 4d | 0d | Project Manager | 8h | Project Stakeholder Management | {4E569C03-4014-4B59-93CA-A65125118FA1} |
| 150 | 5.10.2 | Monitor Stakeholder Satisfaction |  | 1d | 2013-10-23 | 2013-10-23 | 82 | 16d | 12d | Project Director | 8h | Project Stakeholder Management | {E4D951AB-C95A-4B17-AC79-7E34F97E1B8A} |
| 151 | 5.11 | Monitoring and Controlling Complete | milestone | 0d | 2013-11-08 | 2013-11-08 | 119, 120, 121, 122, 123, 125, 126, 128, 130, 131, 132, 134, 135, 136, 138, 139, 140, 142, 143, 145, 147, 149, 150 | 4d |  |  |  |  |  |
| 152 | 6 | **Closing** |  | 5d | 2013-11-15 | 2013-11-21 |  | 0d |  |  | 64h |  | {89B35694-3699-40DC-89DE-8EAE6E7E13A4} |
| 153 | 6.1 | **Project Lessons Learned and Project Archives** |  | 5d | 2013-11-15 | 2013-11-21 |  | 0d |  |  | 56h | Project Integration Management | {61E83402-EF85-4B9F-B7EE-1D7A74C23EB9} |
| 154 | 6.1.1 | Obtain Final Project Acceptance |  | 1d | 2013-11-15 | 2013-11-15 | 116, 151 | 2d |  | Project Director | 8h | Project Integration Management |  |
| 155 | 6.1.2 | Transition Project to Production |  | 1d | 2013-11-18 | 2013-11-18 | 116, 151 | 1d |  | Project Director | 8h | Project Integration Management |  |
| 156 | 6.1.3 | Assess Stakeholder Satisfaction |  | 1d | 2013-11-15 | 2013-11-15 | 116, 151 | 2d |  | Project Manager | 8h | Project Integration Management | {3EF49AB1-E098-4630-80F3-B97AD6F30906} |
| 157 | 6.1.4 | Summarize Project Results and Lessons Learned |  | 1d | 2013-11-18 | 2013-11-18 | 116, 151 | 1d |  | Project Manager | 8h | Project Integration Management | {647A0F0E-ED18-4EA1-B57E-BD966CD4F169} |
| 158 | 6.1.5 | Review and Recognize Team Performance |  | 1d | 2013-11-19 | 2013-11-19 | 116, 151 | 0d |  | Project Manager | 8h | Project Integration Management | {86671FA2-2537-4196-A909-748087596C91} |
| 159 | 6.1.6 | Close Out the Project Records |  | 1d | 2013-11-20 | 2013-11-20 | 154, 155, 156, 157, 158 | 0d |  | Project Manager | 8h | Project Integration Management | {4A084573-5449-4630-AD60-F270649DE126} |
| 160 | 6.1.7 | Review and Reconcile Financial Performance |  | 1d | 2013-11-21 | 2013-11-21 | 159 | 0d |  | Project Manager | 8h | Project Integration Management | {F921128E-12D8-4DBD-BF93-89E1AFD9DD51} |

Notes:
- 133: Manage the monthly cash flow of the project, including the forecasted estimates to complete for the remainder of the project.
- 134: Analyze cost and schedule variances from plan and implement corrective action. / Deliverables: Project Cost/Schedule Performance Report, Action Items / Text7: Project Cost/Schedule Performance Report, Action Items
- 135: Control project costs and expenses so as deliver the project on budget. / Deliverables: Approved Project Charges / Text7: Approved Project Charges
- 136: Reconcile the project's financial data with the corporate financial system and update the financial estimates to complete for the remainder of the project / Deliverables: Financial Plan, Financial Plan / Text7: Financial Plan, Financial Plan
- 137: Implement and manage a program to ensure the project quality and implement continual improvement of work operations.
- 138: Measure and ensure that the project meets defined Quality Standards. / Deliverables: Action Items / Text7: Action Items
- 139: Witness testing, conduct verification testing, and conduct acceptance testing of subcontracted components. / Deliverables: Action Items / Text7: Action Items
- 140: Interpret project measurements as the basis for the continual improvement and optimization of work processes. / Deliverables: Quality Metrics and Trends / Text7: Quality Metrics and Trends
- 141: Monitor and report on the costs, schedule, and technical performance of the project.
- 142: Summarize and communicate the accomplishments for the reporting period, the objectives for the coming period, problems (if any), the status of outstanding risk items, and suggestions for dealing with issues and problems. / Deliverables: Project Weekly Status Report, Risk Management Log, Project Tracking Summary Report, Action Items / Text7: Project Weekly Status Report, Risk Management Log, Project Tracking Summary Report, Action Items
- 143: Keep project status visible to Project Stakeholders by providing an appropriate summary of project status on a regular monthly basis. / Deliverables: Project Monthly Status Report, Action Items / Text7: Project Monthly Status Report, Action Items
- 144: Managing the Risk Register and acting on Risk Management Action Plans as required to ensure the project stays on schedule.
- 145: Manage the Risk Register and the enact Risk Action plans to ensure that risks do not impact the project. / Deliverables: Risk Management Action Plan, Risk Register / Text7: Risk Management Action Plan, Risk Register
- 146: Ensure that all contract terms and conditions, both buyer and seller, are adhered to during the life of the contract
- 147: Manage the relationship between the acquisition organization and the subcontracting organization. / Deliverables: Procurement Management Plan, Contract Files, Subcontractor Payments / Text7: Procurement Management Plan, Contract Files, Subcontractor Payments
- 148: Monitor overall stakeholder relationships and adjust strategies to maintain stakeholder engagement
- 149: Ensure that the project team is provided with the information and decisions necessary to keep the project on track. / Deliverables: Decision Request, Decision Request Log, Information Request, Information Request Log / Text7: Decision Request, Decision Request Log, Information Request, Information Request Log
- 150: Monitor how well the stakeholder's expectations for quality service delivery are being met. / Deliverables: Stakeholder Satisfaction Measures, Action Items / Text7: Stakeholder Satisfaction Measures, Action Items
- 151: Milestone to reflect the end of the Project Management activities on the project
- 152: Close out the project upon completion.
- 153: Make sure that the project is properly closed down, either when project delivery is complete or when the project is terminated for whatever reason.
- 154: Obtain a single and final acceptance of the project consolidating all deliverable acceptances into a single document / Deliverables: Project Acceptance Documents / Text7: Project Acceptance Documents
- 155: Ensure the project's results have been transitioned into operations. / Deliverables: Operational Results / Text7: Operational Results
- 156: Document the overall satisfaction with the project. / Deliverables: Stakeholder Satisfaction Form / Text7: Stakeholder Satisfaction Form
- 157: Work with the project team to capture relevant experience and lessons learned for the benefit of future projects. / Deliverables: Project Summary / Text7: Project Summary
- 158: Complete performance reviews for each team member, recognize efforts and accomplishments, and celebrate success. / Deliverables: Performance Review, Recognition Programs / Text7: Performance Review, Recognition Programs
- 159: Update and archive project documentation and make sure that all close out conditions have been met. / Deliverables: Project Archives, Project Completion / Text7: Project Archives, Project Completion
- 160: Make sure that all invoices have been delivered and all payments made. / Deliverables: Payments / Text7: Payments

| ID | WBS | Task | Type | Duration | Start | Finish | Predecessors | Total slack | Resources | Work | PMBOK Knowledge Area | Text8 | Deliverables | Text7 |
| --- | --- | --- | --- | --- | --- | --- | --- | --- | --- | --- | --- | --- | --- | --- |
| 161 | 6.2 | **Subcontractor Acceptance Documents** |  | 1d | 2013-11-15 | 2013-11-15 |  | 4d |  | 8h | Project Procurement Management | {28B5238A-0916-401D-9756-FD4A8536F500} |  |  |
| 162 | 6.2.1 | Close Subcontractor Contract |  | 1d | 2013-11-15 | 2013-11-15 | 116 | 4d | Contracts Manager | 8h | Project Procurement Management | {14287C35-B087-490B-AD24-3E3C6C3D8B17} | Contract Files, Subcontractor Payments | Contract Files, Subcontractor Payments |
| 163 | 7 | Project Completion | milestone | 0d | 2013-11-21 | 2013-11-21 | 160, 162 | 0d |  |  |  |  |  |  |

Notes:
- 161: Fully close all sub-contracts and release all vendors from project responsibilities
- 162: Specific actions required to ensure acceptance of deliverables, process final payments and archive and close out project contract files.
- 163: Milestone to reflect the end of the Project.
